# Galileo Project Schedule

Schedule from MS Project, 2005-12-01 to 2006-05-26, status date 2005-12-20, A marks actual dates.
EDS: UAF EAP

## Calendars

- Standard: Mon-Sun 08:00-13:00, 13:00-17:00. Exceptions (off unless hours are given): 2005-12-20 08:00-12:00, 13:00-17:00.

## Resources

| Resource | Group |
| --- | --- |
| Coad Steve | RIT SE Team |
| Morris Sandra | RIT SE Team |
| Rericha Tracy | RIT SE Team |
| Simone Elaine | RIT SE Team |
| Manos John | APPLICATIONS DELIVERY-AMERICAS 277336 |
| Whalen Michelle F | APPLICATIONS DELIVERY-AMERICAS 277336 |
| Wilcox Marianne | APPLICATIONS DELIVERY-AMERICAS 277336 |
| Baiera Steve | APPLICATIONS DELIVERY-AMERICAS 277336 |
| Hartnett Bill | APPLICATIONS DELIVERY-AMERICAS 277336 |
| Farmer Jen | APPLICATIONS DELIVERY-AMERICAS 277336 |
| Wu Lei | RIT SE Coach |
| Morris Sandra; Rericha Tracy; Simone Elaine |  |
| NA |  |
| Steve Coad |  |
| Tracy Rericha |  |
| Michelle Whalen |  |
| John Manos |  |
| Lei Wu |  |
| Steve Sullivan |  |
| Steve Baiera |  |
| Marty Ohman |  |
| Sherry Stone |  |
| Elaine Simone |  |
| Sandy Morris |  |
| Jen Farmer |  |
| Don Pecor |  |
| Julian Pisconi |  |
| Darren Bielby |  |
| Ed Jones |  |
| Rudy Vonwald |  |

## Schedule

| ID | WBS | Task | Duration | Start | Finish | Predecessors | Complete | Remaining | Baseline start | Baseline finish | Baseline duration | Total slack | Constraint | Deadline | Resources | Work | Actual work | Text1 | Text3 |
| --- | --- | --- | --- | --- | --- | --- | --- | --- | --- | --- | --- | --- | --- | --- | --- | --- | --- | --- | --- |
| 1 | 1 | **FARA Registry Project** | 199d? | 2005-12-01 A | 2006-05-26 |  | 89% | 22.01d? | 2005-12-01 | 2006-05-26 | 199d? | 0d | start no earlier than 2005-12-01 | 2006-05-26 |  | 34718h | 29616.2h |  |  |
| 2 | 1.1 | **Start Up and Planning** | 48.25d? | 2005-12-01 A | 2006-01-12 A |  | 100% |  | 2005-12-01 | 2006-01-04 | 39.25d? |  |  |  |  | 1277.04h | 1277.04h |  |  |
| 3 | 1.1.1 | Conduct SU & P Workshop | 1.13d | 2005-12-01 A | 2005-12-02 A |  | 100% |  | 2005-12-01 | 2005-12-01 | 1.12d |  | finish no earlier than 2005-12-01 |  | Whalen Michelle F | 9.04h | 9.04h |  |  |
| 4 | 1.1.2 | Finalize SU & P Documents\Components | 6.75d | 2005-12-10 A | 2005-12-15 A |  | 100% |  | 2005-12-10 | 2005-12-19 | 11.25d |  | start no earlier than 2005-12-10 |  | Coad Steve; Morris Sandra; Rericha Tracy; Simone Elaine | 216h | 216h |  |  |
| 5 | 1.1.3 | Initial draft of SE department website | 5.62d? | 2005-12-06 A | 2005-12-10 A |  | 100% |  | 2005-12-06 | 2005-12-10 | 5.62d? |  | finish no earlier than 2005-12-10 |  | Coad Steve | 45h | 45h | Steve Coad | Steve Coad |
| 6 | 1.1.4 | Finish SE department website with artifcats | 38.12d? | 2005-12-10 A | 2006-01-12 A |  | 100% |  | 2005-12-10 | 2005-12-10 | 7.88d? |  | finish no earlier than 2005-12-16 |  | Coad Steve | 305h | 305h | Steve Coad | Steve Coad |
| 7 | 1.1.5 | Finalize Project plan, schedule, and process | 21.94d? | 2005-12-10 A | 2006-01-04 A |  | 100% |  | 2005-12-10 | 2006-01-04 | 29.25d? |  | finish no earlier than 2006-01-04 |  | Coad Steve; Morris Sandra; Simone Elaine; Rericha Tracy | 702h | 702h | Tracy Rericha | Tracy Rericha |
| 8 | 1.2 | **Project Execution** | 191.12d? | 2005-12-01 A | 2006-05-19 |  | 95% | 9.81d? | 2005-12-01 | 2006-05-19 | 191.12d? | 7.88d |  |  |  | 29247h | 28069.2h |  |  |
| 9 | 1.2.1 | Attend Project Meetings | 191.12d? | 2005-12-01 A | 2006-05-19 A |  | 100% |  | 2005-12-01 | 2006-05-19 | 1d? |  | finish no earlier than 2006-04-28 |  | Morris Sandra; Coad Steve; Rericha Tracy; Simone Elaine; Manos John; Farmer Jen; Whalen Michelle F; Wu Lei | 12232h | 12232h | RIT Team | RIT Team |
| 10 | 1.2.2 | Update Metrics on website | 2d? | 2005-12-01 A | 2005-12-02 |  | 20% | 1.6d? | 2005-12-01 | 2006-05-19 | 0d? | 197d |  |  | Coad Steve; Rericha Tracy | 32h | 6.4h | Tracy Rericha | Tracy Rericha |
| 11 | 1.2.3 | **Analyze** | 15.75d | 2005-12-06 A | 2005-12-19 A |  | 100% |  | 2005-12-01 | 2005-12-19 | 21.38d |  |  |  |  | 575h | 575h |  |  |
| 12 | 1.2.3.1 | Define High Level Requirements | 9d | 2005-12-06 A | 2005-12-13 A |  | 100% |  | 2005-12-01 | 2005-12-15 | 16.88d |  | start no earlier than 2005-12-01 |  | Farmer Jen; Morris Sandra; Coad Steve; Simone Elaine; Rericha Tracy; Whalen Michelle F; Manos John | 504h | 504h | Tracy Rericha | RIT Team |
| 13 | 1.2.3.2 | Analyze Phase Review \ Resolve Issues | 1.12d | 2005-12-19 A | 2005-12-19 A |  | 100% |  | 2005-12-15 | 2005-12-15 | 5.62d |  | finish no earlier than 2005-12-19 |  | Coad Steve; Morris Sandra; Rericha Tracy; Simone Elaine; Manos John; Whalen Michelle F; Farmer Jen | 63h | 63h | RIT Team | RIT Team |
| 14 | 1.2.3.3 | Obtain Customer Signoff on High Level Requirements | 0.5d | 2005-12-15 A | 2005-12-15 A |  | 100% |  | 2005-12-15 | 2005-12-15 | 1d |  | start no earlier than 2005-12-15 |  | Farmer Jen; Rericha Tracy | 8h | 8h | Tracy Rericha | Tracy Rericha |
| 15 | 1.2.4 | **Define** | 73d? | 2005-12-01 A | 2006-02-03 A |  | 100% |  | 2005-12-10 | 2006-01-27 | 55d? |  |  |  |  | 3969h | 3969h |  |  |
| 16 | 1.2.4.1 | Schedule JAD Sessions | 1.12d | 2005-12-10 A | 2005-12-10 A |  | 100% |  | 2005-12-10 | 2005-12-10 | 1.12d |  | finish no earlier than 2005-12-10 |  | Rericha Tracy | 9h | 9h | Tracy Rericha | Tracy Rericha |
| 17 | 1.2.4.2 | Create a Solution Prototype | 22.5d | 2005-12-09 A | 2005-12-29 A |  | 100% |  | 2005-12-15 | 2006-01-04 | 22.5d |  | finish no earlier than 2006-01-04 |  | Coad Steve; Morris Sandra; Rericha Tracy; Simone Elaine | 720h | 720h | RIT Team | RIT Team |
| 18 | 1.2.4.3 | Conduct JAD Session to Determine Detailed Requirements | 2.25d? | 2006-01-06 A | 2006-01-07 A |  | 100% |  | 2006-01-06 | 2006-01-07 | 2.25d? |  | start no earlier than 2006-01-06 |  | Coad Steve; Morris Sandra; Rericha Tracy; Simone Elaine; Whalen Michelle F; Manos John; Farmer Jen | 126h | 126h | RIT Team | RIT Team |
| 19 | 1.2.4.4 | Document Detailed Requirements | 14.5d? | 2006-01-12 A | 2006-01-24 A | 18 | 100% |  | 2006-01-12 | 2006-01-12 | 1d? |  | finish no earlier than 2006-01-12 |  | Coad Steve; Morris Sandra; Rericha Tracy; Simone Elaine | 464h | 464h | RIT Team | RIT Team |
| 20 | 1.2.4.5 | Define Phase Review \ Resolve Issues | 3.38d? | 2006-01-24 A | 2006-01-26 A |  | 100% |  | 2006-01-12 | 2006-01-19 | 9d? |  | finish no earlier than 2006-01-19 |  | Coad Steve; Morris Sandra; Rericha Tracy; Simone Elaine; Whalen Michelle F; Manos John; Farmer Jen | 189h | 189h | RIT Team | RIT Team |
| 21 | 1.2.4.6 | Obtain Customer Signoff on Detailed Requirements | 3.38d? | 2006-01-24 A | 2006-01-26 A |  | 100% |  | 2006-01-19 | 2006-01-19 | 1d? |  | start no earlier than 2006-01-19 |  | Farmer Jen; Rericha Tracy | 54h | 54h | Tracy Rericha | Tracy Rericha |
| 22 | 1.2.4.7 | Set up development environment | 1d? | 2006-01-23 A | 2006-01-23 A | 21 | 100% |  | 2006-01-23 | 2006-01-24 | 0d? |  |  |  | Coad Steve | 8h | 8h | Steve Coad | Steve Coad |
| 23 | 1.2.4.8 | Update Requirements Traceability document | 3.38d? | 2006-01-26 A | 2006-01-28 A | 22 | 100% |  | 2006-01-26 | 2006-01-27 | 0d? |  |  |  | Simone Elaine | 27h | 27h | Elaine Simone | Elaine Simone |
| 24 | 1.2.4.9 | Obtain Signoff on Requirements Traceability document | 4.5d? | 2006-01-31 A | 2006-02-03 A | 23 | 100% |  | 2006-01-31 | 2006-01-31 | 0d? |  |  |  | Rericha Tracy | 36h | 36h | Tracy Rericha | Tracy Rericha |
| 25 | 1.2.4.10 | Validate Project Schedule | 1.12d? | 2006-01-26 A | 2006-01-26 A |  | 100% |  | 2006-01-24 | 2006-01-24 | 1d? |  | start no earlier than 2006-01-24 |  | Coad Steve; Morris Sandra; Rericha Tracy; Simone Elaine | 36h | 36h | Tracy Rericha | Tracy Rericha |
| 26 | 1.2.4.11 | Validate Estimate | 71.88d? | 2005-12-01 A | 2006-02-02 A |  | 100% |  | 2006-01-25 | 2006-02-02 | 0d? |  |  |  | Coad Steve; Morris Sandra; Rericha Tracy; Simone Elaine | 2300h | 2300h | Sandy Morris | Sandy Morris |

Notes:
- 13: Includes resolving all issues

| ID | WBS | Task | Duration | Start | Finish | Predecessors | Complete | Remaining | Baseline start | Baseline finish | Baseline duration | Total slack | Constraint | Resources | Work | Actual work | Text1 | Text3 |
| --- | --- | --- | --- | --- | --- | --- | --- | --- | --- | --- | --- | --- | --- | --- | --- | --- | --- | --- |
| 27 | 1.2.5 | **Design** | 139.38d? | 2005-12-01 A | 2006-04-03 |  | 99% | 0.79d? | 2006-01-12 | 2006-02-23 | 48.38d? | 59.62d |  |  | 4538.96h | 4530.96h |  |  |
| 28 | 1.2.5.1 | Learn development environment | 40.5d? | 2006-01-30 A | 2006-03-06 A |  | 100% |  | 2006-01-31 | 2006-01-31 | 0d? |  |  | Morris Sandra; Rericha Tracy; Simone Elaine | 324h | 324h | Steve Coad | RIT Team |
| 29 | 1.2.5.2 | Modularity Document Signoff | 37.12d? | 2006-01-07 A | 2006-02-08 A |  | 100% |  | 2006-02-07 | 2006-02-08 | 0d? |  |  | Coad Steve; Rericha Tracy; Whalen Michelle F; Manos John | 1188h | 1188h | Tracy Rericha | Steve Coad |
| 30 | 1.2.5.3 | Create Initial Context, System and Architecture Diagrams | 13.5d | 2006-01-01 A | 2006-01-12 A |  | 100% |  | 2006-01-19 | 2006-01-12 | 3.38d |  | finish no earlier than 2006-01-12 | Simone Elaine | 108h | 108h | Tracy Rericha | Elaine Simone |
| 31 | 1.2.5.4 | Document Design | 23.62d | 2006-01-25 A | 2006-02-14 A |  | 100% |  | 2006-01-12 | 2006-01-24 | 14.62d |  | finish no earlier than 2006-01-24 | Coad Steve; Rericha Tracy | 378h | 378h | Steve Coad | RIT Team |
| 32 | 1.2.5.5 | Create Unit Test Cases | 2.25d? | 2006-02-11 A | 2006-02-14 A |  | 100% |  | 2006-02-14 | 2006-02-21 | 9d? |  | finish no earlier than 2006-02-21 | Morris Sandra; Simone Elaine | 36h | 36h | Tracy Rericha | Elaine Simone, Sandy Morris |
| 33 | 1.2.5.6 | Design Phase Review / Resolve Issues | 1.12d? | 2006-02-16 A | 2006-02-16 A |  | 100% |  | 2006-02-16 | 2006-02-16 | 0d? |  |  | Coad Steve; Morris Sandra; Rericha Tracy; Simone Elaine; Manos John; Farmer Jen; Whalen Michelle F | 63h | 63h | RIT Team | Tracy Rericha, Steve Coad |
| 34 | 1.2.5.7 | Unit Test Case Review / Resolve Issues | 1.12d? | 2006-02-24 A | 2006-02-24 A | 33 | 100% |  | 2006-02-16 | 2006-02-16 | 0d? |  |  | Coad Steve; Morris Sandra; Rericha Tracy; Simone Elaine; Manos John; Whalen Michelle F; Farmer Jen | 63h | 63h | RIT Team | Elaine Simone, Sandy Morris |
| 35 | 1.2.5.8 | Resolve Issues and Re-Review Design | 8.91d? | 2006-02-17 A | 2006-02-24 A | 34 | 100% |  | 2006-02-17 | 2006-02-22 | 0d? |  |  | Coad Steve; Morris Sandra; Rericha Tracy; Simone Elaine; Manos John; Whalen Michelle F; Farmer Jen | 498.96h | 498.96h | RIT Team | Tracy Rericha, Steve Coad |
| 36 | 1.2.5.9 | Resolve Issues and Re-Review Unit Test Cases | 9d? | 2006-02-17 A | 2006-02-24 A | 35 | 100% |  | 2006-02-17 | 2006-02-22 | 0d? |  |  | Coad Steve; Morris Sandra; Rericha Tracy; Simone Elaine; Manos John; Whalen Michelle F | 432h | 432h | RIT Team | Elaine Simone, Sandy Morris |
| 37 | 1.2.5.10 | Complete interim evaluations | 5.62d? | 2006-02-20 A | 2006-02-24 A |  | 100% |  | 2006-02-20 | 2006-02-24 | 1d? |  | start no earlier than 2006-02-20 | Coad Steve; Morris Sandra; Rericha Tracy; Simone Elaine; Manos John; Whalen Michelle F; Farmer Jen; Wu Lei | 360h | 360h | RIT Team | RIT Team |
| 38 | 1.2.5.11 | Prepare for interim status project presentation | 14.62d? | 2006-02-10 A | 2006-02-22 A |  | 100% |  | 2006-02-13 | 2006-02-21 | 33.75d? |  | finish no earlier than 2006-02-21 | Coad Steve; Morris Sandra; Rericha Tracy; Simone Elaine | 468h | 468h | RIT Team | RIT Team |
| 39 | 1.2.5.12 | Database Signoff (part of Design) | 1.12d? | 2006-03-16 A | 2006-03-16 A |  | 100% |  | 2006-03-16 | 2006-03-16 | 0d? |  |  | Rericha Tracy; Coad Steve; Manos John; Whalen Michelle F | 36h | 36h | Tracy Rericha | Tracy Rericha |
| 40 | 1.2.5.13 | Design Signoff | 1.12d? | 2006-02-23 A | 2006-02-23 A |  | 100% |  | 2006-02-23 | 2006-02-23 | 0d? |  |  | Rericha Tracy; Farmer Jen; Whalen Michelle F; Manos John | 36h | 36h | Tracy Rericha | Tracy Rericha |
| 41 | 1.2.5.14 | Unit Test Cases Signoff | 16.88d? | 2006-03-20 A | 2006-04-03 A |  | 100% |  | 2006-02-23 | 2006-02-23 | 0d? |  |  | Rericha Tracy; Farmer Jen; Whalen Michelle F; Manos John | 540h | 540h | Tracy Rericha | Tracy Rericha |
| 42 | 1.2.5.15 | Model Office and Production Env Stand Up | 1d? | 2005-12-01 | 2005-12-01 |  |  |  | 2006-02-01 | 2006-02-01 | 1d? | 198d |  | Manos John | 8h |  | Steve Coad | John Manos |
| 43 | 1.2.6 | **Produce** | 172d? | 2005-12-01 A | 2006-05-02 |  | 96% | 7.19d? | 2006-02-23 | 2006-04-28 | 73.12d? | 27d |  |  | 6695.01h | 6467.81h |  |  |
| 44 | 1.2.6.1 | Validate Estimate and Project Schedule | 1.12d? | 2006-02-23 A | 2006-02-23 A |  | 100% |  | 2006-02-23 | 2006-02-23 | 1d? |  | start no earlier than 2006-02-23 | Rericha Tracy | 9h | 9h | Tracy Rericha | Tracy Rericha |
| 45 | 1.2.6.2 | Create End User Procedures | 18d? | 2006-04-17 A | 2006-05-02 |  | 60% | 7.2d? | 2006-03-14 | 2006-03-21 | 9d? | 27d | finish no earlier than 2006-03-21 | Farmer Jen | 144h | 86.4h | Elaine Simone | Jen Farmer |
| 46 | 1.2.6.3 | Define and Document Needed System Test Cases | 4.5d | 2006-03-30 A | 2006-04-02 |  | 60% | 1.8d | 2006-02-24 | 2006-03-03 | 9d | 60.75d | finish no earlier than 2006-03-03 | Simone Elaine; Coad Steve | 72h | 43.2h | Steve Coad | Elaine Simone |
| 47 | 1.2.6.4 | Define and Document User Acceptance Test (UAT) Cases | 73.12d? | 2006-01-26 A | 2006-03-31 A |  | 100% |  | 2006-01-20 | 2006-01-28 | 0d? |  |  | Farmer Jen | 585h | 585h | Sandy Morris | Jen Farmer |
| 48 | 1.2.6.5 | RIT Team Exam week | 5.62d? | 2006-02-27 A | 2006-03-03 A |  | 100% |  | 2006-02-27 | 2006-03-03 | 0d? |  |  | Coad Steve; Morris Sandra; Rericha Tracy; Simone Elaine | 180h | 180h | RIT Team | RIT Team |
| 49 | 1.2.6.6 | RIT Spring break | 5.62d? | 2006-03-06 A | 2006-03-10 A |  | 100% |  | 2006-03-06 | 2006-03-10 | 0d? |  |  | Coad Steve; Morris Sandra; Rericha Tracy; Simone Elaine | 180h | 180h | RIT Team | RIT Team |
| 50 | 1.2.6.7 | Review Evolutionary Prototpye with Customer (UI Review) | 1.12d? | 2006-03-31 A | 2006-03-31 A |  | 100% |  | 2006-03-17 | 2006-03-17 | 0d? |  |  | Coad Steve; Morris Sandra; Rericha Tracy; Simone Elaine; Farmer Jen; Manos John; Whalen Michelle F | 63h | 63h | RIT Team | RIT Team |
| 51 | 1.2.6.8 | .NET Training session | 1d? | 2005-12-01 A | 2005-12-01 A |  | 100% |  | 2006-03-20 | 2006-03-20 | 0d? |  |  | Coad Steve; Morris Sandra; Rericha Tracy; Simone Elaine; Manos John | 40h | 40h | RIT Team | RIT Team |
| 52 | 1.2.6.9 | Module 1 Completion - Database | 39.38d? | 2006-02-17 A | 2006-03-23 A |  | 100% |  | 2006-02-24 | 2006-03-22 | 0d? |  |  | Coad Steve | 315h | 315h | Tracy Rericha | Steve Coad |
| 53 | 1.2.6.10 | Module 2 Completion - User Authentication/Login | 20.25d? | 2006-03-22 A | 2006-04-08 A |  | 100% |  | 2006-03-22 | 2006-04-01 | 0d? |  |  | Coad Steve | 162h | 162h | Elaine Simone | Steve Coad |
| 54 | 1.2.6.11 | Module 3 Completion - Data Entry View | 50.62d? | 2006-02-24 A | 2006-04-09 A |  | 100% |  | 2006-02-24 | 2006-03-30 | 0d? |  |  | Morris Sandra | 405h | 405h | Steve Coad | Sandy Morris |
| 55 | 1.2.6.12 | Module 4 Completion - Data Entry Logic | 49.5d? | 2006-02-24 A | 2006-04-08 A |  | 100% |  | 2006-03-18 | 2006-03-30 | 0d? |  |  | Simone Elaine | 396h | 396h | Sandy Morris | Elaine Simone |
| 56 | 1.2.6.13 | Module 5 Completion - Patient Update | 50.62d? | 2006-02-24 A | 2006-04-09 A |  | 100% |  | 2006-02-24 | 2006-04-03 | 0d? |  |  | Rericha Tracy | 405h | 405h | Sandy Morris | Tracy Rericha |
| 57 | 1.2.6.14 | Module 6 Completion - Patient Review | 52.88d? | 2006-02-24 A | 2006-04-11 A |  | 100% |  | 2006-03-23 | 2006-04-10 | 0d? |  |  | Rericha Tracy | 423h | 423h | Sandy Morris | Tracy Rericha |
| 58 | 1.2.6.15 | Module 7 Completion - Admin | 24.75d? | 2006-03-31 A | 2006-04-21 A |  | 100% |  | 2006-03-31 | 2006-04-07 | 0d? |  |  | Coad Steve | 198h | 198h | Tracy Rericha | Steve Coad |
| 59 | 1.2.6.16 | Module 8 Completion - Querying | 64.12d? | 2006-02-24 A | 2006-04-21 A |  | 100% |  | 2006-02-24 | 2006-04-06 | 0d? |  |  | Simone Elaine | 513h | 513h | Steve Coad | Elaine Simone |
| 60 | 1.2.6.17 | Module 9 Completion - Registry auto-maint. | 1d? | 2006-04-07 A | 2006-04-07 |  | 90% | 0.1d? | 2006-04-07 | 2006-04-14 | 0d? | 55.25d |  | Coad Steve | 8h | 7.2h | Elaine Simone | Steve Coad |
| 61 | 1.2.6.18 | Module 10 Completion - Static Site Content | 20.25d? | 2006-03-23 A | 2006-04-09 A |  | 100% |  | 2006-03-23 | 2006-04-03 | 0d? |  |  | Morris Sandra | 162h | 162h | Tracy Rericha | Sandy Morris |
| 62 | 1.2.6.19 | Module 1 Review | 1.12d? | 2006-03-24 A | 2006-03-24 A |  | 100% |  | 2006-03-24 | 2006-03-24 | 0d? |  |  | Michelle Whalen; Tracy Rericha; Steve Coad; John Manos; Lei Wu; Steve Sullivan; Steve Baiera; Marty Ohman; Sherry Stone | 81h | 81h | RIT Team | RIT Team |
| 63 | 1.2.6.20 | Module 2, 3, and 4 Review | 1.12d? | 2006-04-10 A | 2006-04-10 A |  | 100% |  | 2006-04-10 | 2006-04-10 | 0d? |  |  | Sandy Morris; Elaine Simone; Steve Coad; Michelle Whalen; John Manos; Lei Wu; Steve Sullivan; Steve Baiera; Marty Ohman | 81h | 81h | RIT Team | RIT Team |
| 64 | 1.2.6.21 | Module 5, 6, and 7 Review | 1.12d? | 2006-04-12 A | 2006-04-12 A |  | 100% |  | 2006-04-12 | 2006-04-12 | 0d? |  |  | Steve Coad; Sandy Morris; Tracy Rericha; Michelle Whalen; John Manos; Lei Wu; Steve Sullivan; Steve Baiera; Marty Ohman | 81h | 81h | RIT Team | RIT Team |
| 65 | 1.2.6.22 | Module 8, 9, and 10 Review | 1.12d? | 2006-04-17 A | 2006-04-17 A |  | 100% |  | 2006-04-17 | 2006-04-17 | 0d? |  |  | Michelle Whalen; Elaine Simone; Steve Coad; John Manos; Lei Wu; Steve Sullivan; Steve Baiera; Marty Ohman; Rericha Tracy; Morris Sandra | 90h | 90h | RIT Team | RIT Team |
| 66 | 1.2.6.23 | Define and document a system testing plan | 11.25d? | 2006-04-05 A | 2006-04-14 |  | 60% | 4.5d? | 2006-03-14 | 2006-04-14 | 11.25d? | 47.25d | finish no earlier than 2006-03-23 | Simone Elaine | 90h | 54h | Steve Coad | Elaine Simone |
| 67 | 1.2.6.24 | Define and document a UAT testing plan | 22.5d? | 2006-04-05 A | 2006-04-24 |  | 60% | 9d? | 2006-03-14 | 2006-04-14 | 11.25d? | 36d | finish no earlier than 2006-03-23 | Morris Sandra | 180h | 108h | Sandy Morris | Jen Farmer |
| 68 | 1.2.6.25 | Produce Phase Review \ Resolve Issues | 6.75d? | 2006-04-21 A | 2006-04-26 A |  | 100% |  | 2006-04-21 | 2006-04-26 | 9d? |  | finish no earlier than 2006-04-28 | Steve Coad; Tracy Rericha; Lei Wu; Jen Farmer; John Manos; Michelle Whalen; Elaine Simone; Sandy Morris; Steve Sullivan; Steve Baiera; Marty Ohman | 594h | 594h | RIT Team | RIT Team |
| 69 | 1.2.6.26 | Testing Phase Review \ Resolve Issues | 0.41d? | 2006-04-24 A | 2006-04-24 A |  | 100% |  | 2006-04-22 | 2006-04-24 | 9d? |  | finish no earlier than 2006-04-28 | Steve Coad; Tracy Rericha; Lei Wu; Jen Farmer; John Manos; Michelle Whalen; Elaine Simone; Sandy Morris; Steve Sullivan; Steve Baiera; Marty Ohman | 36.01h | 36.01h | RIT Team | RIT Team |
| 70 | 1.2.6.27 | End User Procedures review | 1d? | 2005-12-01 | 2005-12-01 |  |  |  | 2006-05-02 | 2006-05-05 | 0d? | 198d |  | Coad Steve; Morris Sandra; Rericha Tracy; Simone Elaine | 32h |  | Elaine Simone | Jen Farmer |
| 71 | 1.2.6.28 | UAT Test Cases Review / Resolve Issues | 19.12d? | 2006-03-31 A | 2006-04-16 A |  | 100% |  | 2006-03-31 | 2006-04-14 | 0d? |  |  | Coad Steve; Morris Sandra; Rericha Tracy; Simone Elaine; Farmer Jen; Whalen Michelle F | 918h | 918h | RIT Team | RIT Team |
| 72 | 1.2.6.29 | UAT Signoff | 15.75d? | 2006-04-03 A | 2006-04-16 A |  | 100% |  | 2006-04-03 | 2006-04-07 | 0d? |  |  | Jen Farmer; Elaine Simone | 252h | 252h | Elaine Simone | Jen Farmer |

| ID | WBS | Task | Duration | Start | Finish | Predecessors | Complete | Remaining | Baseline start | Baseline finish | Baseline duration | Total slack | Free slack | Constraint | Resources | Work | Actual work | Text1 | Text3 |
| --- | --- | --- | --- | --- | --- | --- | --- | --- | --- | --- | --- | --- | --- | --- | --- | --- | --- | --- | --- |
| 73 | 1.2.7 | **Optimize** | 187.75d? | 2005-12-01 A | 2006-05-16 |  | 21% | 148.58d? | 2006-04-26 | 2006-05-16 | 23.62d? | 11.25d |  |  |  | 1169h | 288h |  |  |
| 74 | 1.2.7.1 | Create plan to move code from RIT dev to mod dev | 5.62d | 2006-04-21 A | 2006-04-25 A |  | 100% |  | 2006-04-21 | 2006-04-24 | 9d |  |  | finish no earlier than 2006-05-05 | Coad Steve; Morris Sandra; Rericha Tracy; Simone Elaine | 180h | 180h | Steve Coad | RIT Team |
| 75 | 1.2.7.2 | Execute move from RIT to model (webhost4life) plan | 1.12d? | 2006-04-27 A | 2006-04-27 A |  | 100% |  | 2006-04-27 | 2006-04-27 | 0d? |  |  |  | Coad Steve; Morris Sandra; Rericha Tracy; Simone Elaine; Manos John; Whalen Michelle F | 54h | 54h | RIT Team | RIT Team |
| 76 | 1.2.7.3 | System Testing kickoff | 1.12d? | 2006-04-26 A | 2006-04-26 A |  | 100% |  | 2006-04-26 | 2006-04-26 | 0d? |  |  |  | Coad Steve; Morris Sandra; Rericha Tracy; Simone Elaine; Manos John; Whalen Michelle F | 54h | 54h | RIT Team | RIT Team |
| 77 | 1.2.7.4 | Meet with those who will be taking over system | 1d? | 2005-12-01 | 2005-12-01 |  |  |  | 2006-05-01 | 2006-05-01 | 0d? | 198d |  |  | Coad Steve; Morris Sandra; Rericha Tracy; Simone Elaine; Manos John; Whalen Michelle F; Farmer Jen | 56h |  | RIT Team | RIT Team |
| 78 | 1.2.7.5 | Execute System Testing \ Resolve Defects | 11.25d? | 2006-04-28 A | 2006-05-07 |  |  | 11.25d? | 2006-04-28 | 2006-05-07 | 11.25d? | 21.38d |  | finish no earlier than 2006-05-07 | Coad Steve; Morris Sandra; Rericha Tracy; Simone Elaine | 360h |  | Elaine Simone | RIT Team |
| 79 | 1.2.7.6 | Create plan to move code from model dev to production dev | 1d? | 2005-12-01 | 2005-12-01 |  |  |  | 2006-05-01 | 2006-05-06 | 0d? | 198d |  |  | Coad Steve; Morris Sandra; Rericha Tracy; Simone Elaine; Manos John; Whalen Michelle F | 48h |  | Steve Coad | RIT Team |
| 80 | 1.2.7.7 | Review production implementation plan | 1d? | 2005-12-01 | 2005-12-01 |  |  |  | 2006-05-08 | 2006-05-12 | 0d? | 198d |  |  | Coad Steve; Morris Sandra; Rericha Tracy; Simone Elaine; Manos John; Whalen Michelle F | 48h |  | Steve Coad | RIT Team |
| 81 | 1.2.7.8 | Build Environment For UAT Testing | 3.38d? | 2006-05-05 | 2006-05-07 |  |  |  | 2006-05-05 | 2006-05-07 | 3.38d? | 21.38d |  | finish no earlier than 2006-05-07 | Coad Steve | 27h |  | Steve Coad | RIT Team |
| 82 | 1.2.7.9 | First UAT session | 1d? | 2005-12-01 | 2005-12-01 |  |  |  | 2006-05-08 | 2006-05-08 | 0d? | 198d |  |  |  |  |  | RIT Team | RIT Team |
| 83 | 1.2.7.10 | Execute UAT Testing \ Resolve Defects | 10.12d? | 2006-05-08 | 2006-05-16 |  |  |  | 2006-05-08 | 2006-05-16 | 10.12d? | 11.25d |  | start no earlier than 2006-05-08 | Coad Steve; Morris Sandra; Rericha Tracy; Simone Elaine | 324h |  | Sandy Morris | RIT Team |
| 84 | 1.2.7.11 | Obtain UAT Customer Signoff | 1.12d? | 2006-05-16 | 2006-05-16 |  |  |  | 2006-05-16 | 2006-05-16 | 1.12d? | 11.25d |  | finish no earlier than 2006-05-16 | Farmer Jen; Rericha Tracy | 18h |  | Tracy Rericha | RIT Team |
| 85 | 1.2.8 | **Implement** | 1.12d? | 2006-05-19 | 2006-05-19 |  |  |  | 2006-05-17 | 2006-05-19 | 1.12d? | 7.88d |  |  |  | 36h |  |  |  |
| 86 | 1.2.8.1 | Execute move from model to production plan | 1.12d? | 2006-05-19 | 2006-05-19 |  |  |  | 2006-05-17 | 2006-05-19 | 1.12d? | 7.88d |  | start no earlier than 2006-05-19 | Coad Steve; Morris Sandra; Rericha Tracy; Simone Elaine | 36h |  | Steve Coad | RIT Team |
| 87 | 1.3 | **Project Closedown** | 45d? | 2006-04-17 A | 2006-05-26 |  | 12% | 39.73d? | 2006-04-17 | 2006-05-26 | 45d? | 0d |  |  |  | 4194h | 270h |  |  |
| 88 | 1.3.1 | Prepare for final project presentation | 9d? | 2006-05-15 | 2006-05-22 |  |  |  | 2006-05-08 | 2006-05-15 | 9d? | 4.5d |  | finish no earlier than 2006-05-22 | Coad Steve; Morris Sandra; Rericha Tracy; Simone Elaine | 288h |  | RIT Team | RIT Team |
| 89 | 1.3.2 | Prepare SE project poster | 11.25d? | 2006-04-17 A | 2006-04-26 A |  | 100% |  | 2006-04-17 | 2006-04-26 | 12.38d? |  |  | finish no earlier than 2006-04-27 | Morris Sandra; Rericha Tracy; Simone Elaine | 270h | 270h | Tracy Rericha | RIT Team |
| 90 | 1.3.3 | Project Technical report | 13.5d? | 2006-05-01 | 2006-05-12 |  |  |  | 2006-05-01 | 2006-05-12 | 13.5d? | 15.75d |  | start no earlier than 2006-05-01 | Coad Steve; Morris Sandra; Rericha Tracy; Simone Elaine | 432h |  | Steve Coad | RIT Team |
| 91 | 1.3.4 | Complete final evaluations | 13.5d? | 2006-05-15 | 2006-05-26 |  |  |  | 2006-05-15 | 2006-05-19 | 13.5d? | 0d |  | finish no earlier than 2006-05-26 | Coad Steve; Morris Sandra; Rericha Tracy; Simone Elaine; Manos John; Whalen Michelle F; Farmer Jen; Wu Lei | 864h |  | RIT Team | RIT Team |
| 92 | 1.3.5 | **Transition to EDS** | 39.67d? | 2006-04-21 | 2006-05-26 |  |  |  | 2006-04-21 | 2006-05-27 | 0d? | 0.38d |  |  |  | 2340h |  |  |  |
| 93 | 1.3.5.1 | Create Transition Plan | 0.67d? | 2006-04-21 | 2006-04-21 |  |  |  | 2006-04-21 | 2006-04-21 | 0d? | 37.88d | 30.38d | finish no earlier than 2006-04-21 | Coad Steve; Morris Sandra; Rericha Tracy; Simone Elaine; Manos John; Whalen Michelle F | 32h |  |  |  |
| 94 | 1.3.5.2 | Kickoff Testing Meeting | 1h | 2006-04-26 | 2006-04-26 |  |  |  | 2006-04-26 | 2006-04-26 | 0d? | 32.25d | 24.75d | finish no earlier than 2006-04-26 | Coad Steve; Morris Sandra; Rericha Tracy; Simone Elaine; Manos John; Whalen Michelle F | 6h |  |  |  |
| 95 | 1.3.5.3 | Create Team Roles & Responsibilities Doc | 0.67d? | 2006-04-28 | 2006-04-28 |  |  |  | 2006-04-28 | 2006-04-28 | 0d? | 30d | 22.5d | finish no earlier than 2006-04-28 | Coad Steve; Morris Sandra; Rericha Tracy; Simone Elaine; Manos John; Whalen Michelle F | 32h |  |  |  |
| 96 | 1.3.5.4 | Meet the students Meeting | 1h | 2006-04-28 | 2006-04-28 |  |  |  | 2006-04-28 | 2006-04-28 | 0d? | 31d | 23.5d | start no earlier than 2006-04-28 | Coad Steve; Morris Sandra; Rericha Tracy; Simone Elaine; Manos John; Whalen Michelle F | 6h |  |  |  |
| 97 | 1.3.5.5 | Student Presentation | 0.67d? | 2006-05-15 | 2006-05-15 |  |  |  | 2006-05-15 | 2006-05-15 | 0d? | 10.88d | 3.38d | finish no earlier than 2006-05-15 | Coad Steve; Morris Sandra; Rericha Tracy; Simone Elaine; Manos John; Whalen Michelle F | 32h |  |  |  |
| 98 | 1.3.5.6 | Systems Testing | 7.5d? | 2006-05-01 | 2006-05-07 |  |  |  | 2006-04-28 | 2006-05-07 | 0d? | 13.12d | 0d | finish no earlier than 2006-05-07 | Coad Steve; Morris Sandra; Rericha Tracy; Simone Elaine; Manos John; Whalen Michelle F | 360h |  |  |  |
| 99 | 1.3.5.7 | UAT Testing | 6.75d? | 2006-05-08 | 2006-05-13 | 98 |  |  | 2006-05-08 | 2006-05-16 | 0d? | 13.12d | 5.62d | start no earlier than 2006-05-08 | Coad Steve; Morris Sandra; Rericha Tracy; Simone Elaine; Manos John; Whalen Michelle F | 324h |  |  |  |
| 100 | 1.3.5.8 | Create Code Repository | 13.5d? | 2006-04-28 | 2006-05-09 |  |  |  | 2006-04-28 | 2006-05-15 | 0d? | 17.62d | 10.12d | start no earlier than 2006-04-28 | Coad Steve; Morris Sandra; Rericha Tracy; Simone Elaine; Manos John; Whalen Michelle F | 648h |  |  |  |
| 101 | 1.3.5.9 | Review Code in Model Office | 11.25d? | 2006-05-01 | 2006-05-10 |  |  |  | 2006-05-01 | 2006-05-15 | 0d? | 16.5d | 9d | start no earlier than 2006-05-01 | Coad Steve; Morris Sandra; Rericha Tracy; Simone Elaine; Manos John; Whalen Michelle F | 540h |  |  |  |
| 102 | 1.3.5.10 | Complete Transition Activities | 0.75d? | 2006-05-19 | 2006-05-19 | 93, 94, 95, 96, 97, 98, 99, 100, 101 |  |  | 2006-05-19 | 2006-05-19 | 0d? | 7.5d | 7.12d | start no earlier than 2006-05-19 | Coad Steve; Morris Sandra; Rericha Tracy; Simone Elaine; Manos John; Whalen Michelle F | 36h |  |  |  |
| 103 | 1.3.5.11 | EDS and RIT production support transition | 6d? | 2006-05-19 | 2006-05-24 |  |  |  | 2006-05-19 | 2006-05-26 | 0d? | 2.25d | 1.88d | start no earlier than 2006-05-19 | Coad Steve; Morris Sandra; Rericha Tracy; Simone Elaine; Manos John; Whalen Michelle F | 288h |  |  |  |
| 104 | 1.3.5.12 | Final Hand Off | 0.75d? | 2006-05-26 | 2006-05-26 | 102, 103 |  |  | 2006-05-27 | 2006-05-27 | 0d? | 0.38d |  | start no earlier than 2006-05-26 | Coad Steve; Morris Sandra; Rericha Tracy; Simone Elaine; Manos John; Whalen Michelle F | 36h |  |  |  |
